# ESTUDIO DEFINITIVO DE LA CARRETERA CAMACA - DV QUILCA - MATARANI - ILO - TACNA

Schedule from MS Project, 2014-01-01 to 2016-06-18.

## Calendars

- Estándar: Mon-Sun 08:00-13:00, 14:00-17:00.

## Resources

| Resource | Group | Unit | Rate | Cost per use |
| --- | --- | --- | --- | --- |
| TOPOGRAFO | Mano de Obra |  | 14.34 |  |
| NIVELADOR | Mano de Obra |  | 14.34 |  |
| OPERARIO | Mano de Obra |  | 11.95 |  |
| OFICIAL | Mano de Obra |  | 10.69 |  |
| PEON | Mano de Obra |  | 9.66 |  |
| CAPATAZ "B" | Mano de Obra |  | 14.34 |  |
| CAPATAZ "A" | Mano de Obra |  | 15.54 |  |
| ALAMBRE NEGRO # 16 | Material | kg |  | 3.05 |
| ALAMBRE NEGRO # 8 | Material | kg |  | 3.05 |
| CLAVOS DIFERENTES MEDIDAS | Material | kg |  | 3.05 |
| PERNOS 3/8" X 8" + T + A | Material | pza |  | 2.53 |
| PERNOS 5/8" X 8" | Material | pza |  | 5.35 |
| ACERO CORRUGADO fy=4200 kg/cm2 GRADO 60 | Material | kg |  | 2.45 |
| LAMINA REFLECTIVA ALTA INTENSIDAD | Material | p2 |  | 12.89 |
| FILLER | Material | kg |  | 0.43 |
| ARENA DE SÍLICE | Material | m3 |  | 38.5 |
| ASFALTO LIQUIDO MC-30 | Material | gal |  | 7.2 |
| EMULSIÓN ASFÁLTICA | Material | gal |  | 6.22 |
| CEMENTO ASFALTICO MODIFICADO CON POLÍMEROS | Material | gal |  | 11.51 |
| CEMENTO PORTLAND TIPO I (42.5 kg) | Material | bls |  | 17.42 |
| YESO DE 28 Kg | Material | bls |  | 24.36 |
| SOLVENTE XILOL | Material | gal |  | 19.61 |
| THINNER STANDARD | Material | gal |  | 20.01 |
| PLANTAS NATIVAS | Material | kg |  | 60 |
| OXIGENO | Material | m3 |  | 18.51 |
| ACETILENO | Material | m3 |  | 48.17 |
| SOLDADURA (AWS E6011) | Material | kg |  | 8.33 |
| BARRENO 5' X 1/8" | Material | u |  | 311.69 |
| DESMOLDANTE PARA MADERA | Material | gal |  | 29.42 |
| MATERIAL DE RESPALDO PARA SELLADORES | Material |  |  | 5.15 |
| MASILLA PLASTICA BITUMINOSA | Material | kg |  | 5.57 |
| IMPRIMANTE ASFÁLTICO MODIFICADO | Material | kg |  | 20.98 |
| ACCESORIOS Y PEGAMENTO | Material | %MT |  |  |
| ADITIVO CURADOR | Material | gal |  | 16.92 |
| ADITIVO ADHESIVO EPÓXICO | Material | gal |  | 307.55 |
| FIBRA DE VIDRIO DE 4 mm ACABADO | Material | m2 |  | 127.69 |
| ADITIVO MEJORADOR DE ADHERENCIA | Material | kg |  | 16.92 |
| TINTA XEROGRÁFICA NEGRA | Material | gal |  | 1146.8 |
| TINTA XEROGRÁFICA ROJA | Material | gal |  | 1146.8 |
| GEOTEXTIL CLASE 2 | Material | m2 |  | 2.91 |
| TEKNOPOR DE 3/4" | Material | m2 |  | 1.9 |
| ESCOBILLA DE ACERO | Material | pza |  | 1.2 |
| WAYPE INDUSTRIAL | Material | kg |  | 4.34 |
| MADERA TORNILLO | Material | p2 |  | 3.98 |
| TRIPLAY DE 19 mm PARA ENCOFRADO | Material | pl |  | 90.63 |
| GAVION TIPO CAJA 10 X 12 CM 3.4 MM | Material | m3 |  | 81.48 |
| TEE DE ACERO LIVIANO DE 1 1/2" X 1 1/2" X 3/16" X 6 m | Material | pza |  | 53.04 |
| PLATINA DE ACERO 2" X 1/8" | Material |  |  | 4.22 |
| GUARDAVIA METALICA | Material |  |  | 42.94 |
| PERNO Y TUERCA DE GUARDAVIAS | Material | jgo |  | 21.01 |
| POSTE DE ACERO DE 1.80M X 6MM P/GUARDAVIA | Material | u |  | 88.34 |
| TERMINAL T-1 | Material | u |  | 40.58 |
| TERMINAL T-2 | Material | u |  | 60.85 |
| CAPTAFAROS | Material | u |  | 11.66 |
| POSTE DE ACERO DE 2.40M X 6MM P/GUARDAVIA | Material | u |  | 117.77 |
| PINTURA ANTICORROSIVA | Material | gal |  | 24.47 |
| PINTURA IMPRIMANTE | Material | gal |  | 15.08 |
| PINTURA ESMALTE | Material | gal |  | 28.64 |
| PINTURA PARA TRAFICO | Material | gal |  | 52.74 |
| MICROESFERAS DE VIDRIO | Material | kg |  | 4.81 |
| PINTURA WASH PRIMER | Material | gal |  | 146.32 |
| ACERO ESTRUCTURAL GRADO 36 | Material |  |  | 3100 |
| TUBO DE FIERRO NEGRO STD. Ø3" | Material |  |  | 36.73 |
| TUBERIA PVC SAP C-10 DE 2" | Material |  |  | 7.45 |
| TUBERIA PVC SAP C-10 DE 8" | Material |  |  | 86.93 |
| HERRAMIENTAS MANUALES | Equipo |  | 8 |  |
| JALONES | Equipo |  | 0.75 |  |
| MIRA TOPOGRAFICA | Equipo |  | 0.98 |  |
| MOTOSIERRA DE 30" | Equipo |  | 5.8 |  |
| EQUIPO DE PINTURA AIRLESS | Equipo |  | 25.49 |  |
| EQUIPO DE GRANALLADO | Equipo |  | 29.15 |  |
| MEZCLADORA DE CONCRETO DE 11p3 18 HP | Equipo |  | 41.04 |  |
| CAMION CISTERNA 4 X 2 (AGUA) 122 HP 2 000 gl | Equipo |  | 119.57 |  |
| CAMION VOLQUETE 15 m3 | Equipo |  | 190.18 |  |
| EQUIPO DE OXICORTE | Equipo |  | 2.51 |  |
| ENCOFRADO METALICO | Equipo |  | 8.25 |  |
| COMPRESORA NEUMATICA 250-330 PCM 87 HP | Equipo |  | 72.54 |  |
| COMPACTADOR VIBRATORIO TIPO PLANCHA 7 HP | Equipo |  | 23.48 |  |
| RODILLO LISO VIBRATORIO AUTOPROPULSADO 101-135HP 10-12 ton | Equipo |  | 100.54 |  |
| RODILLO LISO VIBRATORIO AUTOPROPULSADO 70-100 HP 7-9 ton | Equipo |  | 76.83 |  |
| RODILLO NEUMATICO AUTOPROPULSADO 135 HP 9-26 ton | Equipo |  | 88.29 |  |
| RODILLO NEUMATICO AUTOPROPULSADO 81-100HP 5.5-20 ton | Equipo |  | 71.31 |  |
| RODILLO TANDEM ESTATICO AUTOPROPULSADO 58-70HP 8-10 ton | Equipo |  | 53.2 |  |
| CARGADOR SOBRE LLANTAS 100-115 HP 2-2.25 yd3 | Equipo |  | 126.35 |  |
| CARGADOR SOBRE LLANTAS 200-250 HP 4-4.1 yd3 | Equipo |  | 221.76 |  |
| RETROEXCAVADOR SOBRE ORUGA 80-110HP 0.5-1.3 YD3 | Equipo |  | 160.92 |  |
| TRACTOR DE ORUGAS DE 190-240 HP | Equipo |  | 254.02 |  |
| TRACTOR SOBRE LLANTAS DE 200-250 HP | Equipo |  | 239.57 |  |
| BARREDORA MECANICA 10-20 HP 7 p LONGITUD | Equipo |  | 42.25 |  |
| CALENTADOR DE ACEITE 5 HP 468 p3 | Equipo |  | 44.13 |  |
| COCINA DE ASFALTO 320 gl | Equipo |  | 33.02 |  |
| SECADOR ARIDOS MOTOR EQUIPO 50 HP 30-65 ton/h | Equipo |  | 38.26 |  |
| FRESADORA DE PAVIMENTO RS-500B | Equipo |  | 475.5 |  |
| PAVIMENTADORA SOBRE ORUGAS 105 HP 10-16' | Equipo |  | 111.93 |  |
| CAMION GRAVILLADOR 11.8 M3 | Equipo |  | 253.6 |  |
| MARTILLO NEUMATICO DE 29 kg | Equipo |  | 24.02 |  |
| VIBRADOR DE CONCRETO 4 HP 1.50" | Equipo |  | 18.37 |  |
| MOTOSOLDADORA DE 225 A | Equipo |  | 27.6 |  |
| ZARANDA VIBRATORIA 4" X 6" X 14" MOTOR ELECTRICO 15 HP | Equipo |  | 33.8 |  |
| TRACTOR DE TIRO DE 80 HP | Equipo |  | 67.35 |  |
| CHANCADORA PRIMARIA SECUNDARIA 5 FAJAS 75 HP 46 - 70 ton/h | Equipo |  | 186.08 |  |
| MOTONIVELADORA DE 125 HP | Equipo |  | 131.11 |  |
| MOTONIVELADORA DE 145-150 HP | Equipo |  | 165.21 |  |
| CAMIONETA PICK UP 4 X 2 90 HP 2 ton | Equipo |  | 55.7 |  |
| GRUPO ELECTROGENO 116 HP 75 KW | Equipo |  | 58.3 |  |
| GRUPO ELECTROGENO 230 HP 150 KW | Equipo |  | 108.93 |  |
| FAJA TRANSPORTADORA 18" X 4' MOTOR ELECTRICO 3 KW 150 ton/h | Equipo |  | 25.93 |  |
| NIVEL TOPOGRAFICO | Equipo |  | 7.77 |  |
| MAQUINA PARA PINTAR MARCAS EN PAVIMENTO | Equipo |  | 45 |  |
| CORTADORA DE PAVIMENTO INCLUYE DISCO | Equipo |  | 35 |  |
| PLANTA DE ASFALTO DE 30/60 ton/h | Equipo |  | 57.36 |  |
| CAMION IMPRIMADOR DE 1800 gl | Equipo |  | 159.94 |  |
| GRUA HIAB SOBRE CAMION DE 5 ton | Equipo |  | 153.35 |  |
| TEODOLITO | Equipo |  | 9.62 |  |
| MOVILIZACIÓN Y DESMOVILIZACIÓN DE EQUIPOS | Subcontrato |  |  | 307748 |
| MANTENIMIENTO DE TRÁNSITO Y SEGURIDAD VIAL | Subcontrato |  |  | 402274 |
| SERVICIO DE SERIGRAFIA EN UN COLOR | Subcontrato |  |  | 7.88 |
| SERVICIO DE SERIGRAFIA EN DOS COLORES | Subcontrato |  |  | 30.29 |

## Schedule

| ID | WBS | Task | Type | Duration | Start | Finish | Predecessors | Total slack | Free slack | Constraint | Cost | Text1 |
| --- | --- | --- | --- | --- | --- | --- | --- | --- | --- | --- | --- | --- |
| 1 | 1 | INICIO DE OBRA | milestone | 0d | 2014-01-01 | 2014-01-01 |  | 0d |  | start no earlier than 2014-01-01 |  |  |
| 2 | 2 | **OBRAS PRELIMINARES** |  | 900d | 2014-01-01 | 2016-06-18 |  | 0d |  |  | 6,787,361.33 | 100 |
| 3 | 2.1 | MOVILIZACIÓN Y DESMOVILIZACIÓN DE EQUIPOS |  | 900d | 2014-01-01 | 2016-06-18 | 1SS | 0d |  | start no earlier than 2012-07-01 | 4,399,445.96 | 101.A |
| 4 | 2.2 | TOPOGRAFIA Y GEOREFERENCIACION |  | 120d | 2014-01-04 | 2014-05-03 | 3SS+3d | 777d |  |  | 173,607.52 | 102.A |
| 5 | 2.3 | MANTENIMIENTO DE TRÁNSITO Y SEGURIDAD VIAL |  | 900d | 2014-01-01 | 2016-06-18 | 3SS | 0d |  |  | 892,617.3 | 103.A |
| 6 | 2.4 | ACCESOS A CANTERAS, BOTADERO, PLANTAS Y FUENTE DE AGUA |  | 120d | 2014-01-06 | 2014-05-05 | 3SS+5d | 775d |  |  | 1,321,690.55 | 107.A |
| 7 | 3 | **MOVIMIENTO DE TIERRAS** |  | 600d | 2014-01-01 | 2015-08-23 |  | 0d |  |  | 110,797,219.83 | 200 |
| 8 | 3.1 | DESBROCE Y LIMPIEZA EN ZONAS NO BOSCOSAS |  | 350d | 2014-01-06 | 2014-12-21 | 2SS+5d | 15d | 0d |  | 1,389.06 | 201.B |
| 9 | 3.2 | EXCAVACIÓN EN ROCA FIJA |  | 550d | 2014-01-06 | 2015-07-09 | 10SS | 15d | 0d |  | 47,637,012.97 | 205.B1 |
| 10 | 3.3 | EXCAVACIÓN EN ROCA SUELTA |  | 450d | 2014-01-06 | 2015-03-31 | 11SS | 15d | 0d |  | 12,227,849.32 | 205.B2 |
| 11 | 3.4 | EXCAVACIÓN EN MATERIAL COMUN |  | 550d | 2014-01-06 | 2015-07-09 | 8SS | 15d | 0d |  | 5,612,324.93 | 205.C |
| 12 | 3.5 | PERFILADO Y COMPACTADO DE SUBRASANTE EN ZONA DE CORTE |  | 550d | 2014-02-05 | 2015-08-08 | 9SS+30d | 15d | 0d |  | 1,880,809.37 | 205.E |
| 13 | 3.6 | REMOCIÓN DE DERRUMBES |  | 450d | 2014-02-20 | 2015-05-15 | 12SS+15d | 100d |  |  | 186,957.66 | 206.A |
| 14 | 3.7 | CONFORMACION DE TERRAPLENES |  | 500d | 2014-02-20 | 2015-07-04 | 12SS+15d | 35d | 0d |  | 20,822,019.19 | 210.A |
| 15 | 3.8 | CONFORMACION DE TERRAPLENES PARA H>1.50 m |  | 600d | 2014-01-01 | 2015-08-23 |  | 0d |  |  | 11,923,982.06 | 210.A1 |
| 16 | 3.9 | CORTE PARA MEJORAMIENTO A NIVEL DE SUBRASANTE |  | 450d | 2014-03-07 | 2015-05-30 | 14SS+15d | 85d |  |  | 123,819.17 | 220.B1 |
| 17 | 3.10 | CONFORMACION DE MEJORAMIENTO A NIVEL DE SUBRASANTE |  | 450d | 2014-03-07 | 2015-05-30 | 14SS+15d | 85d |  | start no earlier than 2011-10-31 | 592,831.17 | 220.B2 |
| 18 | 3.11 | MATERIAL DE CANTERA PARA RELLENOS |  | 500d | 2014-03-07 | 2015-07-19 | 14SS+15d | 35d | 0d |  | 9,578,192.42 | 230.A |
| 19 | 3.12 | BANQUETAS PARA RELLENOS |  | 450d | 2014-04-06 | 2015-06-29 | 18SS+30d | 55d |  |  | 210,032.51 | 242.A |
| 20 | 4 | **SUB BASE Y BASE** |  | 800d | 2014-02-15 | 2016-04-24 |  | 55d |  |  | 16,906,614.88 | 300 |
| 21 | 4.1 | SUB BASE GRANULAR |  | 300d | 2014-12-12 | 2015-10-07 | 7FF+45d | 255d |  |  | 6,933,502.83 | 303.A |
| 22 | 4.2 | BASE GRANULAR |  | 300d | 2014-12-12 | 2015-10-07 | 7FF+45d | 0d |  |  | 9,413,297.04 | 305.A |
| 23 | 4.3 | LAVADO DE MATERIAL GRANULAR |  | 800d | 2014-02-15 | 2016-04-24 | 24FF | 55d |  | start no earlier than 2014-01-31 | 559,815.01 | 315.A |
| 24 | 5 | **PAVIMENTO ASFÁLTICO** |  | 490d | 2014-12-22 | 2016-04-24 |  | 0d |  |  | 46,097,488.8 | 400 |
| 25 | 5.1 | IMPRIMACIÓN ASFÁLTICA |  | 250d | 2014-12-22 | 2015-08-28 | 22SS+10d | 0d |  |  | 783,812.1 | 401.A |
| 26 | 5.2 | PAVIMENTO DE CONCRETO ASFÁLTICO EN CALIENTE |  | 300d | 2015-06-30 | 2016-04-24 | 25FS-60d | 0d |  | start no earlier than 2015-04-22 | 11,536,466.44 | 410.A |
| 27 | 5.3 | CEMENTO ASFÁLTICO PEN 60-70 |  | 300d | 2015-06-30 | 2016-04-24 | 26SS | 0d |  |  | 28,170,173.44 | 420.B |
| 28 | 5.4 | ASFALTO DILUIDO TIPO MC-30 |  | 300d | 2015-06-30 | 2016-04-24 | 26SS | 0d |  |  | 4,467,729.32 | 422.A |
| 29 | 5.5 | FILLER MINERAL |  | 300d | 2015-06-30 | 2016-04-24 | 26SS | 0d |  |  | 840,569.52 | 423.A |
| 30 | 5.6 | ADITIVO MEJORADOR DE ADHERENCIA |  | 300d | 2015-06-30 | 2016-04-24 | 26SS | 0d |  |  | 298,737.98 | 424.A |

| ID | WBS | Task | Duration | Start | Finish | Predecessors | Total slack | Free slack | Constraint | Cost | Text1 |
| --- | --- | --- | --- | --- | --- | --- | --- | --- | --- | --- | --- |
| 31 | 6 | **OBRAS DE ARTE Y DRENAJE** | 565d | 2014-02-01 | 2015-08-19 |  | 304d |  |  | 36,370,111.76 | 600 |
| 32 | 6.1 | EXCAVACION NO CLASIFICADA PARA ESTRUCTURAS | 400d | 2014-04-02 | 2015-05-06 | 3SS+60d | 374d | 30d | start no earlier than 2014-04-02 | 2,056,954.27 | 601.A |
| 33 | 6.2 | RELLENOS PARA ESTRUCTURAS | 330d | 2014-05-17 | 2015-04-11 | 32SS+15d | 344d | 0d | start no earlier than 2014-05-17 | 7,074,150.45 | 605.A |
| 34 | 6.3 | FILTRO DRENANTE | 350d | 2014-02-01 | 2015-01-16 |  | 519d |  | start no earlier than 2014-02-01 | 12,922.33 | 607.A |
| 35 | 6.4 | MATERIAL IMPERMIABLE | 370d | 2014-02-01 | 2015-02-05 |  | 499d |  | start no earlier than 2014-02-01 | 2,006.22 | 608.A |
| 36 | 6.5 | CONCRETO CLASE D (F'C = 210 KG/CM2) | 360d | 2014-07-16 | 2015-07-10 | 33SS+60d | 344d |  |  | 152,230.99 | 610.D |
| 37 | 6.6 | CONCRETO CLASE E (F'C = 175 KG/CM2) | 420d | 2014-05-17 | 2015-07-10 | 33SS | 344d | 0d |  | 525,899.04 | 610.E |
| 38 | 6.7 | CONCRETO CLASE G (F'C = 175 KG/CM2 + 30% P.M) | 360d | 2014-07-16 | 2015-07-10 | 39SS+60d | 344d |  |  | 126,205 | 610.G |
| 39 | 6.8 | CONCRETO CLASE H (F'C = 100 KG/CM2) | 420d | 2014-05-17 | 2015-07-10 | 37SS | 344d | 0d |  | 61,476.27 | 610.H |
| 40 | 6.9 | CONCRETO CLASE I (F'C = 245 KG/CM2) | 230d | 2014-02-01 | 2014-09-18 |  | 639d |  | start no earlier than 2014-02-01 | 1,822,152.96 | 610.I |
| 41 | 6.10 | ENCOFRADO Y DESENCOFRADO | 420d | 2014-05-17 | 2015-07-10 | 39SS | 344d | 0d |  | 1,441,027.67 | 612.A |
| 42 | 6.11 | ACERO DE REFUERZO FY=4200KG/CM2 | 360d | 2014-05-17 | 2015-05-11 | 41SS | 404d | 0d |  | 1,923,373.3 | 615.A |
| 43 | 6.12 | ALCANTARILLA POLIETLENO DE ALTA DENSIDAD (PEA) D=36" | 90d | 2014-06-16 | 2014-09-13 | 42SS+30d | 644d |  |  | 4,173,731.05 | 623.A |
| 44 | 6.13 | TUBO DE PVC-SAP , D=3" | 370d | 2014-02-01 | 2015-02-05 |  | 499d |  | start no earlier than 2014-02-01 | 2,008.31 | 624.B |
| 45 | 6.14 | TUBO DE PVC-SAP , D=4" | 370d | 2014-02-01 | 2015-02-05 |  | 499d |  | start no earlier than 2014-02-01 | 3,046 | 624.C |
| 46 | 6.15 | CUNETA REVESTIDA TIPO 1 | 330d | 2014-02-01 | 2014-12-27 |  | 379d | 0d | start no earlier than 2014-02-01 | 7,783,288.2 | 635.A |
| 47 | 6.16 | CUNETA SIN REVESTIR TIPO 2 | 230d | 2014-02-01 | 2014-09-18 | 46SS | 379d | 75d |  | 349,320.01 | 636.A |
| 48 | 6.17 | ZANJA DE DRENAJE | 150d | 2014-02-01 | 2014-06-30 |  | 719d |  | start no earlier than 2014-02-01 | 33,903.84 | 637.A |
| 49 | 6.18 | JUNTA PARA MUROS | 60d | 2014-02-01 | 2014-04-01 |  | 749d | 61d | start no earlier than 2014-02-01 | 734.88 | 638.A |
| 50 | 6.19 | JUNTA CON WATER STOP D= 9" | 60d | 2014-06-05 | 2014-08-03 |  | 335d | 0d | start no earlier than 2014-06-05 | 6,006.48 | 639.A |
| 51 | 6.20 | EMBOQUILLADO DE PIEDRA E = 0.15M | 60d | 2014-08-04 | 2014-10-02 | 50 | 335d | 31d |  | 1,295,662.92 | 640.A |
| 52 | 6.21 | GEOTEXTIL | 230d | 2014-11-03 | 2015-06-20 | 47FS-30d, 51 | 304d | 0d | start no earlier than 2014-11-03 | 43,753.41 | 650.A |
| 53 | 6.22 | GEOMANTA | 60d | 2015-06-21 | 2015-08-19 | 52 | 304d |  |  | 68,661.5 | 655.A |
| 54 | 6.23 | GEOCOLCHON MARINO CON GEOMALLAS BIAXIALES H<=2.40 m L=8.00 m | 60d | 2014-06-02 | 2014-07-31 | 49 | 688d |  | start no earlier than 2014-06-02 | 3,424,930.1 | 665.A1 |
| 55 | 6.24 | GEOCOLCHON MARINO CON GEOMALLAS BIAXIALES H>2.40 m L=10.00 m | 60d | 2014-06-02 | 2014-07-31 | 49 | 688d |  | start no earlier than 2014-06-02 | 3,720,911.52 | 665.A2 |
| 56 | 6.25 | ENROCADO | 290d | 2014-04-01 | 2015-01-15 |  | 520d |  | start no earlier than 2014-04-01 | 265,755.04 | 671.A |

| ID | WBS | Task | Duration | Start | Finish | Predecessors | Total slack | Free slack | Constraint | Cost | Text1 |
| --- | --- | --- | --- | --- | --- | --- | --- | --- | --- | --- | --- |
| 57 | 7 | **TRANSPORTE** | 845d | 2014-01-01 | 2016-04-24 |  | 55d |  |  | 75,198,179.45 | 700 |
| 58 | 7.1 | TRANSPORTE DE MATERIAL GRANULAR HASTA 1KM | 610d | 2014-03-07 | 2015-11-06 | 14SS+15d | 225d | 0d |  | 15,255,997.28 | 700.A |
| 59 | 7.2 | TRANSPORTE DE MATERIAL GRANULAR DESPUES 1KM | 610d | 2014-03-07 | 2015-11-06 | 58SS | 225d |  |  | 24,771,880.95 | 700.B |
| 60 | 7.3 | TRANSPORTE DE MEZCLA ASFÁLTICA HASTA 1KM | 300d | 2015-06-30 | 2016-04-24 | 26SS | 0d |  |  | 498,468.43 | 700.C |
| 61 | 7.4 | TRANSPORTE DE MEZCLA ASFÁLTICA DESPUES 1KM | 300d | 2015-06-30 | 2016-04-24 | 26SS | 55d |  |  | 1,027,061.84 | 700.D |
| 62 | 7.5 | TRANSPORTE DE MATERIAL A ELIMINAR HASTA 1KM | 630d | 2014-01-06 | 2015-09-27 | 11SS | 265d |  |  | 15,667,403.53 | 700.E |
| 63 | 7.6 | TRANSPORTE DE MATERIAL A ELIMINAR DESPUES 1KM | 630d | 2014-01-06 | 2015-09-27 | 11SS | 265d |  |  | 17,141,491.81 | 700.F |
| 64 | 7.7 | TRANSPORTE DE ROCA HASTA 1KM | 290d | 2014-01-01 | 2014-10-17 |  | 610d |  |  | 48,372.42 | 700.G |
| 65 | 7.8 | TRANSPORTE DE ROCA DESPUES 1KM | 290d | 2014-01-01 | 2014-10-17 |  | 610d |  |  | 53,027.07 | 700.H |
| 66 | 7.9 | TRANSPORTE DE MATERIAL DE DERRUMBE A DME | 435d | 2014-03-07 | 2015-05-15 | 14SS+15d | 400d |  | finish no earlier than 2014-02-25 | 340,186.6 | 700.I |
| 67 | 7.10 | TRANSPORTE DE CONCRETO PREMEZCLADO HASTA 1KM | 540d | 2014-02-01 | 2015-07-25 |  | 329d |  | start no earlier than 2014-02-01 | 159,399.67 | 700.J |
| 68 | 7.11 | TRANSPORTE DE CONCRETO PREMEZCLADO DESPUES 1KM | 540d | 2014-02-01 | 2015-07-25 |  | 329d |  | start no earlier than 2014-02-01 | 234,889.85 | 700.K |
| 69 | 8 | **SEÑALIZACION Y SEGURIDAD VIAL** | 110d | 2016-03-01 | 2016-06-18 |  | 0d |  |  | 15,662,075.82 | 800 |
| 70 | 8.1 | SEÑALES PREVENTIVAS 0.60 x 0.60 m. | 90d | 2016-03-21 | 2016-06-18 | 60FS-35d | 0d |  | finish no earlier than 2016-06-18 | 104,322.62 | 801.E |
| 71 | 8.2 | SEÑAL PREVENTIVA - CHEVRONES (0.30x0.45m) | 90d | 2016-03-21 | 2016-06-18 | 70SS | 0d |  |  | 443,189.76 | 801.F |
| 72 | 8.3 | SEÑAL REGLAMENTARIA TRIANGULARES 0.90 m x 0.90 m. | 90d | 2016-03-21 | 2016-06-18 | 70SS | 0d |  |  | 5,581.8 | 802.D |
| 73 | 8.4 | SEÑAL REGLAMENTARIA RECTANGULAR 0.90 m x 0.60 m. | 90d | 2016-03-21 | 2016-06-18 | 72SS | 0d |  |  | 99,673.6 | 802.I |
| 74 | 8.5 | SEÑALES INFORMATIVAS | 90d | 2016-03-21 | 2016-06-18 | 73SS | 0d |  |  | 48,523.6 | 803.C |
| 75 | 8.6 | SEÑALES INFORMATIVAS RECTANGULARES (0.60 m x 0.45 m.) | 90d | 2016-03-21 | 2016-06-18 | 74SS | 0d |  |  | 9,688.8 | 803.D |
| 76 | 8.7 | POSTES DE SOPORTE DE SEÑALES DE CONCRETO | 90d | 2016-03-21 | 2016-06-18 | 74SS | 0d |  |  | 189,170.8 | 804.A1 |
| 77 | 8.8 | POSTE DE SOPORTE DE SEÑALES DE FIERRO | 90d | 2016-03-21 | 2016-06-18 | 76SS | 0d |  |  | 301,355.99 | 804.A2 |
| 78 | 8.9 | ESTRUCTURA DE SOPORTE DE SEÑALES TIPO E-1 | 90d | 2016-03-21 | 2016-06-18 | 77SS | 0d |  |  | 415,813.84 | 804.B1 |
| 79 | 8.10 | ESTRUCTURA DE SOPORTE DE SEÑALES TIPO E-2 | 90d | 2016-03-21 | 2016-06-18 | 78SS | 0d |  |  | 24,535.71 | 804.B2 |
| 80 | 8.11 | CIMENTACION DE SEÑALES INFORMATIVAS | 90d | 2016-03-21 | 2016-06-18 | 79SS | 0d |  |  | 36,213.66 | 804.E |
| 81 | 8.12 | POSTE DELINEADOR | 90d | 2016-03-21 | 2016-06-18 | 26FS-35d | 0d |  | start no earlier than 2016-03-01 | 338,603.4 | 805.A |
| 82 | 8.13 | TACHA RETROREFLECTIVA | 110d | 2016-03-01 | 2016-06-18 | 26FS-56d | 0d |  | start no earlier than 2016-03-01 | 405,300.99 | 805.B |
| 83 | 8.14 | MARCAS EN EL PAVIMENTO TIPO II | 110d | 2016-03-01 | 2016-06-18 | 26FS-56d | 0d |  | start no earlier than 2016-03-01 | 172,702.69 | 810.A |
| 84 | 8.15 | BARRERA DE SEGURIDAD LATERAL NIVEL DE CONTENCION P3, H3 | 80d | 2016-03-21 | 2016-06-08 | 79SS | 0d |  |  | 13,034,021.55 | 820.A |
| 85 | 8.16 | POSTE DE KILOMETRAJE | 30d | 2016-05-20 | 2016-06-18 | 84FS-20d | 0d |  | finish no earlier than 2016-06-18 | 12,023.54 | 830.A |
| 86 | 8.17 | PINTADO DE PARAPETOS EN MUROS, ALCANTARILLAS Y SARDINELES | 30d | 2016-05-20 | 2016-06-18 | 85FF | 0d |  |  | 21,353.47 | 840.A |

| ID | WBS | Task | Duration | Start | Finish | Predecessors | Total slack | Free slack | Constraint | Cost | Text1 |
| --- | --- | --- | --- | --- | --- | --- | --- | --- | --- | --- | --- |
| 87 | 9 | **PROTECCIÓN AMBIENTAL** | 900d | 2014-01-01 | 2016-06-18 |  | 0d |  |  | 7,037,811.34 | 900 |
| 88 | 9.1 | **PROGRAMA DE CIERRE DE OBRA** | 895d | 2014-01-06 | 2016-06-18 |  | 0d |  |  | 6,868,941.25 | 900 |
| 89 | 9.1.1 | DISPOSICIÓN Y CONFIRMACIÓN DE MATERIAL EXCEDENTE | 630d | 2014-01-06 | 2015-09-27 |  | 265d | 0d | start no earlier than 2014-01-06 | 5,982,874.26 | 906.A |
| 90 | 9.1.2 | READECUACION AMBIENTAL DE CANTERAS DE RIO | 150d | 2016-01-21 | 2016-06-18 | 24FS-95d | 0d |  | start no earlier than 2011-09-11 | 93,614.89 | 907.A1 |
| 91 | 9.1.3 | READECUACION AMBIENTAL DE CANTERAS DE CERRO | 150d | 2016-01-21 | 2016-06-18 | 24FS-95d | 0d |  |  | 707,052.1 | 907.A2 |
| 92 | 9.1.4 | READECUACION AMBIENTAL DE PLANTAS DE TRITURACION Y DE ASFALTO | 150d | 2016-01-21 | 2016-06-18 | 24FS-95d | 0d |  |  | 40,200 | 907.A3 |
| 93 | 9.1.5 | READECUACION AMBIENTAL DEL CAMPAMENTO | 80d | 2016-03-26 | 2016-06-13 |  | 5d | 0d | start no earlier than 2016-03-26 | 33,900 | 907.B1 |
| 94 | 9.1.6 | READECUACION AMBIENTAL DEL PATIO DE MAQUINAS | 80d | 2016-03-26 | 2016-06-13 | 93SS | 5d |  |  | 11,300 | 907.B2 |
| 95 | 9.2 | **SUBPROGRAMA DE SEÑALIZACION AMBIENTAL** | 120d | 2014-01-06 | 2014-05-05 |  | 775d |  |  | 54,123.93 | 910 |
| 96 | 9.2.1 | SEÑAL INFORMATIVA AMBIENTAL | 120d | 2014-01-06 | 2014-05-05 | 89SS | 775d |  | start no earlier than 2014-01-06 | 24,412.33 | 911.A |
| 97 | 9.2.2 | ESTRUCTURA DE SOPORTE DE SEÑALES TIPO E-1 | 120d | 2014-01-06 | 2014-05-05 | 89SS | 775d |  |  | 29,711.6 | 912.A |
| 98 | 9.3 | **PROGRAMA DE MONITOREO AMBIENTAL** | 900d | 2014-01-01 | 2016-06-18 |  | 0d |  |  | 114,746.16 | 970 |
| 99 | 9.3.1 | MONITOREO DE LA CALIDAD DEL AGUA | 900d | 2014-01-01 | 2016-06-18 | 3SS | 0d |  |  | 3,896.16 | 970.A |
| 100 | 9.3.2 | MONITOREO DE LA CALIDAD DEL AIRE | 900d | 2014-01-01 | 2016-06-18 | 3SS | 0d |  |  | 102,300 | 970.B |
| 101 | 9.3.3 | MONITOREO DE NIVEL DE PRESION DE RUIDOS | 900d | 2014-01-01 | 2016-06-18 | 3SS | 0d |  |  | 8,550 | 970.C |
| 102 | 10 | **PUENTES** | 240d | 2014-11-13 | 2015-07-10 |  | 344d |  |  | 19,640,299.76 | 1100 |
| 103 | 10.1 | PUENTES | 240d | 2014-11-13 | 2015-07-10 | 3SS+316d | 344d |  | start no earlier than 2014-10-01 | 19,640,299.76 |  |
